# Sample Project

Schedule from MS Project, 2004-01-01 to 2004-02-08, status date 2002-01-18.
SMARTEAM Implementation
SmarTeam Corp. Ltd

## Calendars

- Standard: Mon-Thu 08:00-12:00, 13:00-17:00; Fri-Sat off; Sun 08:00-12:00, 13:00-17:00.

## Resources

| Resource |
| --- |
| Customer |
| Project Manager / AE |
| AE / Programmer |

## Schedule

| ID | WBS | Task | Type | Duration | Start | Finish | Predecessors | Total slack | Free slack | Constraint | Resources | Work |
| --- | --- | --- | --- | --- | --- | --- | --- | --- | --- | --- | --- | --- |
| 1 | 1 | **Customer project** |  | 27d | 2004-01-01 | 2004-02-08 |  | 0d |  |  |  | 367.92h |
| 2 | 1.1 | **First Phase** |  | 21d | 2004-01-01 | 2004-01-29 |  | 0d |  |  |  | 287.92h |
| 3 | 1.1.1 | **Initialization of Project** |  | 13d | 2004-01-01 | 2004-01-19 |  | 1d |  |  |  | 168h |
| 4 | 1.1.1.1 | Teach Software to Smart Admin |  | 1d | 2004-01-01 | 2004-01-01 |  | 1d | 0d |  | AE / Programmer; Customer | 16h |
| 5 | 1.1.1.2 | Get all customer Data |  | 3d | 2004-01-04 | 2004-01-06 | 4 | 1d | 0d |  | Project Manager / AE; AE / Programmer; Customer | 72h |
| 6 | 1.1.1.3 | Build DB Structure |  | 5d | 2004-01-07 | 2004-01-13 | 5 | 1d | 0d |  | AE / Programmer | 40h |
| 7 | 1.1.1.4 | Build flow charts |  | 3d | 2004-01-14 | 2004-01-19 | 6 | 2d | 0d |  | AE / Programmer; Customer | 32h |
| 8 | 1.1.1.5 | Build User Authorizations |  | 1d | 2004-01-18 | 2004-01-18 | 6 | 9d |  |  | Customer | 8h |
| 9 | 1.1.2 | **Implementation** |  | 10d | 2004-01-14 | 2004-01-27 | 6 | 1d |  |  |  | 39.92h |
| 10 | 1.1.2.1 | .Install Client Server Env |  | 1d | 2004-01-14 | 2004-01-14 |  | 1d | 0d |  | Project Manager / AE | 8h |
| 11 | 1.1.2.2 | Test DB Structure |  | 6d | 2004-01-20 | 2004-01-27 | 7 | 2d |  |  | Customer; AE / Programmer [33%] | 31.92h |
| 12 | 1.1.3 | **Configurating Integrations** |  | 2d | 2004-01-15 | 2004-01-18 | 10 | 1d |  |  |  | 16h |
| 13 | 1.1.3.1 | AutoCAD Mapping |  | 1d | 2004-01-15 | 2004-01-15 |  | 1d | 0d |  | AE / Programmer | 8h |
| 14 | 1.1.3.2 | Solution for Multi Printing |  | 1d | 2004-01-18 | 2004-01-18 | 13 | 1d |  |  | AE / Programmer | 8h |
| 15 | 1.1.4 | **Training at Customer site** |  | 8d | 2004-01-20 | 2004-01-29 | 12 | 0d |  |  |  | 64h |
| 16 | 1.1.4.1 | Users Course |  | 2d | 2004-01-20 | 2004-01-21 |  | 0d |  | start no earlier than 2002-02-10 | AE / Programmer | 16h |
| 17 | 1.1.4.2 | One on One with Maspenot Users |  | 6d | 2004-01-22 | 2004-01-29 | 16 | 0d |  |  | Customer; AE / Programmer | 48h |
| 18 | 1.1.5 | **Close First Phase of Project** |  | 0d | 2004-01-29 | 2004-01-29 | 15 | 0d |  |  |  |  |
| 19 | 1.1.5.1 | Move to Production - Phase I | milestone | 0d | 2004-01-29 | 2004-01-29 |  | 0d |  |  |  |  |
| 20 | 1.2 | **Second Phase** |  | 6d | 2004-02-01 | 2004-02-08 | 2 | 0d |  |  |  | 80h |
| 21 | 1.2.1 | **Configure Product Tree Structure** |  | 2d | 2004-02-01 | 2004-02-02 |  | 0d |  |  |  | 24h |
| 22 | 1.2.1.1 | Configure Items Tree |  | 1d | 2004-02-01 | 2004-02-01 |  | 0d |  |  | Customer; Project Manager / AE | 16h |
| 23 | 1.2.1.2 | Build Items Tree |  | 1d | 2004-02-02 | 2004-02-02 | 22 | 0d |  |  | Project Manager / AE | 8h |
| 24 | 1.2.2 | **Configure ERP Integration** |  | 4d | 2004-02-03 | 2004-02-08 | 21 | 0d |  |  |  | 32h |
| 25 | 1.2.2.1 | Implement ERP (Priority) Interface |  | 2d | 2004-02-03 | 2004-02-04 |  | 0d |  |  | AE / Programmer | 16h |
| 26 | 1.2.2.2 | Test ERP - PDM Interface |  | 2d | 2004-02-05 | 2004-02-08 | 25 | 0d |  |  | Customer | 16h |

| ID | WBS | Task | Type | Duration | Start | Finish | Predecessors | Total slack | Resources | Work |
| --- | --- | --- | --- | --- | --- | --- | --- | --- | --- | --- |
| 27 | 1.2.3 | **Implement SmartBOM** |  | 4d | 2004-02-03 | 2004-02-08 |  | 0d |  | 24h |
| 28 | 1.2.3.1 | Install and Configure SmartBOM |  | 3d | 2004-02-03 | 2004-02-05 | 21 | 0d | Project Manager / AE | 24h |
| 29 | 1.2.3.2 | Teach SmartBOM |  | 1d | 2004-02-08 | 2004-02-08 | 28 | 0d |  |  |
| 30 | 1.2.4 | **Close Second Phase of Project** |  | 0d | 2004-02-08 | 2004-02-08 |  | 0d |  |  |
| 31 | 1.2.4.1 | Move to Production - Phase II | milestone | 0d | 2004-02-08 | 2004-02-08 | 29 | 0d |  |  |
