# SMARTEAM Project Customer oriented

Schedule from MS Project, 2004-01-01 to 2004-04-02.
Implementation
SmarTeam Corp Ltd

## Calendars

- Standard: Mon-Fri 08:00-12:00, 13:00-17:00; Sat-Sun off.

## Resources

| Resource |
| --- |
| ST Project Leader |
| ST Consultant |
| ST Application Engineer |
| ST Programmer |
| ST Trainer |
| PROJECT TEAM |

## Schedule

| ID | WBS | Task | Type | Duration | Start | Finish | Predecessors | Total slack | Constraint | Resources | Work |
| --- | --- | --- | --- | --- | --- | --- | --- | --- | --- | --- | --- |
| 1 | 1 | **SMARTEAM IMPLEMENTATION** |  | 66.12d | 2004-01-01 | 2004-04-02 |  | 0d |  |  | 585h |
| 2 | 1.1 | **Needs Analysis** |  | 12.12d | 2004-01-01 | 2004-01-19 |  | 0d |  |  | 73h |
| 3 | 1.1.1 | Kick Off Meeting | milestone | 4h | 2004-01-01 | 2004-01-01 |  | 0d |  | PROJECT TEAM | 4h |
| 4 | 1.1.2 | **Interviews** |  | 0.62d | 2004-01-05 | 2004-01-06 |  | 0d |  |  | 5h |
| 5 | 1.1.2.1 | Interviews 1 |  | 1h | 2004-01-05 | 2004-01-05 | 3FS+2d | 0d | start no earlier than 2003-09-03 | ST Consultant | 1h |
| 6 | 1.1.2.2 | Interviews 2 |  | 1h | 2004-01-05 | 2004-01-05 | 5 | 0d | start no earlier than 2003-09-04 | ST Consultant | 1h |
| 7 | 1.1.2.3 | Interviews 3 |  | 1h | 2004-01-05 | 2004-01-05 | 6 | 0d | start no earlier than 2003-09-05 | ST Consultant | 1h |
| 8 | 1.1.2.4 | Interviews 4 |  | 1h | 2004-01-05 | 2004-01-05 | 7 | 0d | start no earlier than 2003-09-06 | ST Consultant | 1h |
| 9 | 1.1.2.5 | Interviews 5 |  | 1h | 2004-01-06 | 2004-01-06 | 8 | 0d | start no earlier than 2003-09-07 | ST Consultant | 1h |
| 10 | 1.1.3 | Analyze & Prepare |  | 2d | 2004-01-06 | 2004-01-08 | 9 | 3d |  | ST Project Leader; ST Consultant | 32h |
| 11 | 1.1.4 | Concluding Meeting | milestone | 4d | 2004-01-13 | 2004-01-19 | 9FS+5d, 10 | 0d |  | PROJECT TEAM | 32h |
| 12 | 1.2 | **Functional Workshop** |  | 8.5d | 2004-01-21 | 2004-02-02 |  | 0d |  |  | 76h |
| 13 | 1.2.1 | Build data model |  | 2d | 2004-01-21 | 2004-01-23 | 11FS+2d | 0d |  | ST Consultant; ST Application Engineer | 32h |
| 14 | 1.2.2 | Populate with scenario data |  | 1d | 2004-01-23 | 2004-01-26 | 13 | 0d |  | ST Application Engineer; ST Consultant | 16h |
| 15 | 1.2.3 | Workshop |  | 1d | 2004-01-28 | 2004-01-29 | 14FS+2d | 0d |  | ST Project Leader; ST Consultant; PROJECT TEAM | 24h |
| 16 | 1.2.4 | Evaluate | milestone | 4h | 2004-02-02 | 2004-02-02 | 15FS+2d | 0d |  | PROJECT TEAM | 4h |
| 17 | 1.3 | **Prepare Pilot** |  | 14.5d | 2004-02-02 | 2004-02-23 |  | 0d |  |  | 180h |
| 18 | 1.3.1 | Install environment |  | 1d | 2004-02-02 | 2004-02-03 | 16 | 0d |  | ST Application Engineer | 8h |
| 19 | 1.3.2 | Final data modeling |  | 1d | 2004-02-03 | 2004-02-04 | 18 | 0d |  | ST Consultant; ST Application Engineer | 16h |
| 20 | 1.3.3 | Customization |  | 10d | 2004-02-04 | 2004-02-18 | 19 | 0d |  | ST Programmer | 80h |
| 21 | 1.3.4 | QA |  | 5d | 2004-02-11 | 2004-02-18 | 20FS-5d | 0d |  | ST Application Engineer | 40h |
| 22 | 1.3.5 | Documentation |  | 2d | 2004-02-18 | 2004-02-20 | 21 | 0d |  | ST Application Engineer | 16h |
| 23 | 1.3.6 | Train Project Team |  | 2d | 2004-02-18 | 2004-02-20 | 21 | 0d |  | ST Trainer | 16h |
| 24 | 1.3.7 | Go/No go meeting | milestone | 4h | 2004-02-20 | 2004-02-23 | 23, 22 | 0d |  | PROJECT TEAM | 4h |

Notes:
- 11: A go/no go decision needs to be made for this step. If we feel we do not understand the project objectives well enough or prerequisites are missing we need to bring it up here
- 16: Evaluation determines if we go to the next phase. If not we need to redo this cycle or even start from the needs analysis again
- 24: A pilot can only start if there are no open issues. Don't let yourself be pushed by time / YOU NEVER GET A SECOND PILOT

| ID | WBS | Task | Type | Duration | Start | Finish | Predecessors | Total slack | Free slack | Constraint | Resources | Work |
| --- | --- | --- | --- | --- | --- | --- | --- | --- | --- | --- | --- | --- |
| 25 | 1.4 | **Pilot** |  | 21d | 2004-02-23 | 2004-03-23 |  | 0d |  |  |  | 168h |
| 26 | 1.4.1 | Run pilot |  | 15d | 2004-02-23 | 2004-03-15 | 24 | 0d |  |  | PROJECT TEAM | 120h |
| 27 | 1.4.2 | **Support** |  | 16d | 2004-02-23 | 2004-03-16 |  | 4d |  |  |  |  |
| 28 | 1.4.2.1 | Support 1 |  | 1d | 2004-02-23 | 2004-02-24 | 26SS | 4d | 0d | start no earlier than 2003-10-26 |  |  |
| 29 | 1.4.2.2 | Support 2 |  | 1d | 2004-02-26 | 2004-02-27 | 28FS+2d | 4d | 0d | start no earlier than 2003-10-29 |  |  |
| 30 | 1.4.2.3 | Support 3 |  | 1d | 2004-03-02 | 2004-03-03 | 29FS+2d | 4d | 0d | start no earlier than 2003-11-02 |  |  |
| 31 | 1.4.2.4 | Support 4 |  | 1d | 2004-03-05 | 2004-03-08 | 30FS+2d | 4d | 0d | start no earlier than 2003-11-05 |  |  |
| 32 | 1.4.2.5 | Support 5 |  | 1d | 2004-03-10 | 2004-03-11 | 31FS+2d | 4d | 0d | start no earlier than 2003-11-10 |  |  |
| 33 | 1.4.2.6 | Support 6 |  | 1d | 2004-03-15 | 2004-03-16 | 32FS+2d | 4d |  | start no earlier than 2003-11-12 |  |  |
| 34 | 1.4.3 | Process pilot remarks |  | 5d | 2004-03-15 | 2004-03-22 | 26 | 0d |  |  | PROJECT TEAM | 40h |
| 35 | 1.4.4 | Go/ No Go Meeting | milestone | 1d | 2004-03-22 | 2004-03-23 | 33, 34 | 0d |  |  | PROJECT TEAM | 8h |
| 36 | 1.5 | **Roll Out** |  | 8d | 2004-03-23 | 2004-04-02 |  | 0d |  |  |  | 88h |
| 37 | 1.5.1 | User Documentation |  | 5d | 2004-03-23 | 2004-03-30 | 35 | 0d |  |  | PROJECT TEAM | 40h |
| 38 | 1.5.2 | Hardware installation |  | 2d | 2004-03-23 | 2004-03-25 | 35 | 3d | 0d |  | ST Application Engineer | 16h |
| 39 | 1.5.3 | Software installation |  | 2d | 2004-03-25 | 2004-03-29 | 38 | 3d |  |  | ST Application Engineer | 16h |
| 40 | 1.5.4 | User Training |  | 2d | 2004-03-30 | 2004-04-01 | 37 | 0d |  |  | PROJECT TEAM | 16h |
| 41 | 1.5.5 | Run with the system | milestone | 1d | 2004-04-01 | 2004-04-02 | 39, 40 | 0d |  |  |  |  |

Notes:
- 27: It is important that during the initial stage of the pilot unforeseen issues are detected and work arounds are presented. Don't start with fixing or changing procedures but take the action
- 37: The user documentation should be function oriented. SMARTEAM's on-line help will support the user which button to click.
