# SMARTEAM Project template

Schedule from MS Project, 2004-01-01 to 2004-03-22.
Implementation
SmarTeam Corp Ltd

## Calendars

- Standard: Mon-Fri 08:00-12:00, 13:00-17:00; Sat-Sun off.

## Resources

| Resource |
| --- |
| ST Project Leader |
| ST Consultant |
| ST Application Engineer |
| ST Programmer |
| ST Trainer |
| PROJECT TEAM |

## Schedule

| ID | WBS | Task | Type | Duration | Start | Finish | Predecessors | Total slack | Free slack | Constraint | Resources | Work |
| --- | --- | --- | --- | --- | --- | --- | --- | --- | --- | --- | --- | --- |
| 1 | 1 | **SMARTEAM TEMPLATE IMPLEMENTATION** |  | 57.5d | 2004-01-01 | 2004-03-22 |  | 0d |  |  |  | 440h |
| 2 | 1.1 | **Functional Workshop** |  | 12d | 2004-01-01 | 2004-01-16 |  | 0d |  |  |  | 92h |
| 3 | 1.1.1 | Training of Project team |  | 2.5d | 2004-01-01 | 2004-01-05 |  | 0d |  |  | ST Trainer; ST Consultant | 40h |
| 4 | 1.1.2 | Workshop |  | 2d | 2004-01-12 | 2004-01-14 | 3FS+5d | 0d |  |  | ST Project Leader; ST Consultant; PROJECT TEAM | 48h |
| 5 | 1.1.3 | Evaluate | milestone | 4h | 2004-01-16 | 2004-01-16 | 4FS+2d | 0d |  |  | PROJECT TEAM | 4h |
| 6 | 1.2 | **Prepare Pilot** |  | 7.5d | 2004-01-19 | 2004-01-28 |  | 0d |  |  |  | 68h |
| 7 | 1.2.1 | Install environment |  | 1d | 2004-01-19 | 2004-01-19 | 5 | 0d |  |  | ST Application Engineer | 8h |
| 8 | 1.2.2 | Final data modeling |  | 1d | 2004-01-20 | 2004-01-20 | 7 | 0d |  |  | ST Consultant; ST Application Engineer | 16h |
| 9 | 1.2.3 | Customization |  | 2d | 2004-01-21 | 2004-01-22 | 8 | 0d |  |  | ST Programmer | 16h |
| 10 | 1.2.4 | QA |  | 1d | 2004-01-23 | 2004-01-23 | 9 | 0d |  |  | ST Application Engineer | 8h |
| 11 | 1.2.5 | Documentation |  | 2d | 2004-01-26 | 2004-01-27 | 10 | 0d |  |  | ST Application Engineer | 16h |
| 12 | 1.2.6 | Go/No go meeting | milestone | 4h | 2004-01-28 | 2004-01-28 | 11 | 0d |  |  | PROJECT TEAM | 4h |
| 13 | 1.3 | **Pilot** |  | 30d | 2004-01-28 | 2004-03-10 |  | 0d |  |  |  | 200h |
| 14 | 1.3.1 | Run pilot |  | 15d | 2004-01-28 | 2004-02-18 | 12 | 0d |  |  | PROJECT TEAM | 120h |
| 15 | 1.3.2 | **Support** |  | 22d | 2004-01-28 | 2004-02-27 |  | 0d |  |  |  | 48h |
| 16 | 1.3.2.1 | Support 1 |  | 2d | 2004-01-28 | 2004-01-30 | 14SS | 0d |  | start no earlier than 2003-10-26 | ST Application Engineer [50%] | 8h |
| 17 | 1.3.2.2 | Support 2 |  | 2d | 2004-02-03 | 2004-02-05 | 16FS+2d | 0d |  | start no earlier than 2003-10-29 | ST Application Engineer [50%] | 8h |
| 18 | 1.3.2.3 | Support 3 |  | 2d | 2004-02-09 | 2004-02-11 | 17FS+2d | 0d |  | start no earlier than 2003-11-02 | ST Application Engineer [50%] | 8h |
| 19 | 1.3.2.4 | Support 4 |  | 2d | 2004-02-13 | 2004-02-17 | 18FS+2d | 0d |  | start no earlier than 2003-11-05 | ST Application Engineer [50%] | 8h |
| 20 | 1.3.2.5 | Support 5 |  | 2d | 2004-02-19 | 2004-02-23 | 19FS+2d | 0d |  | start no earlier than 2003-11-10 | ST Application Engineer [50%] | 8h |
| 21 | 1.3.2.6 | Support 6 |  | 2d | 2004-02-25 | 2004-02-27 | 20FS+2d | 0d |  | start no earlier than 2003-11-12 | ST Application Engineer [50%] | 8h |
| 22 | 1.3.3 | Process remarks |  | 5d | 2004-03-02 | 2004-03-09 | 21FS+2d | 0d |  |  | ST Project Leader [20%]; ST Application Engineer [60%]; ST Programmer [20%] | 24h |
| 23 | 1.3.3 | Go/ No Go Meeting | milestone | 1d | 2004-03-09 | 2004-03-10 | 22 | 0d |  |  | PROJECT TEAM | 8h |
| 24 | 1.4 | **Roll Out** |  | 8d | 2004-03-10 | 2004-03-22 |  | 0d |  |  |  | 80h |
| 25 | 1.4.1 | User Documentation |  | 5d | 2004-03-10 | 2004-03-17 | 23 | 0d |  |  | PROJECT TEAM | 40h |
| 26 | 1.4.2 | Hardware installation |  | 2d | 2004-03-10 | 2004-03-12 | 23 | 4d | 0d |  | ST Application Engineer | 16h |
| 27 | 1.4.3 | Software installation |  | 1d | 2004-03-12 | 2004-03-15 | 26 | 4d |  |  | ST Application Engineer | 8h |
| 28 | 1.4.4 | User Training |  | 2d | 2004-03-17 | 2004-03-19 | 25 | 0d |  |  | PROJECT TEAM | 16h |
| 29 | 1.4.5 | Run with the system | milestone | 1d | 2004-03-19 | 2004-03-22 | 27, 28 | 0d |  |  |  |  |

Notes:
- 4: Goal from this workshop is to define deltas between the template and company needed functionallity. In general the goal is to focus on procedures not on programming custom behavior
- 5: Evaluation determines if we go to the next phase. If not we need to redo this cycle or even start from the needs analysis again
